# timeline

Schedule from MS Project, 2003-08-02 to 2003-09-07.
mbari

## Calendars

- 24 Hours: Mon-Sun 00:00-24:00.

## Schedule

| ID | WBS | Task | Duration | Start | Finish | Predecessors | Total slack | Free slack | Constraint |
| --- | --- | --- | --- | --- | --- | --- | --- | --- | --- |
| 1 | 1 | **Modelling** | 8.12d | 2003-08-02 22:00 | 2003-08-05 15:00 |  | 99.12d |  |  |
| 2 | 1.1 | **ROMS Modelling** | 6.75d | 2003-08-02 22:00 | 2003-08-05 04:00 |  | 99.56d |  |  |
| 3 | 1.1.1 | ROMS Modelling 1 | 6h | 2003-08-02 22:00 | 2003-08-03 04:00 |  | 105.56d | 0.5d | start no earlier than 2003-08-02 22:00 |
| 4 | 1.1.2 | ROMS Modelling 2 | 6h | 2003-08-03 22:00 | 2003-08-04 04:00 |  | 102.56d | 0.5d | start no earlier than 2003-08-03 22:00 |
| 5 | 1.1.3 | ROMS Modelling 3 | 6h | 2003-08-04 22:00 | 2003-08-05 04:00 |  | 99.56d | 0.5d | start no earlier than 2003-08-04 22:00 |
| 6 | 1.2 | **HOPS Modelling Activity** | 7.5d | 2003-08-03 03:00 | 2003-08-05 15:00 |  | 99.12d |  |  |
| 7 | 1.2.1 | **Data Conversion** | 6.88d | 2003-08-03 03:00 | 2003-08-05 10:00 |  | 99.12d |  |  |
| 8 | 1.2.1.1 | Data Conversion 1 | 0.5h | 2003-08-03 03:00 | 2003-08-03 03:30 |  | 99.12d | 0d | start no earlier than 2003-08-03 03:00 |
| 9 | 1.2.1.2 | Data Conversion 2 | 0.5h | 2003-08-03 09:30 | 2003-08-03 10:00 | 8FS+6h | 99.12d | 0d |  |
| 10 | 1.2.1.3 | Data Conversion 3 | 0.5h | 2003-08-04 03:00 | 2003-08-04 03:30 | 72FS+12h | 99.12d | 0d |  |
| 11 | 1.2.1.4 | Data Conversion 4 | 0.5h | 2003-08-04 09:30 | 2003-08-04 10:00 | 10FS+6h | 99.12d | 0d |  |
| 12 | 1.2.1.5 | Data Conversion 5 | 0.5h | 2003-08-05 03:00 | 2003-08-05 03:30 | 74FS+12h | 99.12d | 0d |  |
| 13 | 1.2.1.6 | Data Conversion 6 | 0.5h | 2003-08-05 09:30 | 2003-08-05 10:00 | 12FS+6h | 99.12d | 0d |  |
| 14 | 1.2.2 | **Data Quality Control** | 6.88d | 2003-08-03 03:30 | 2003-08-05 10:30 |  | 99.12d |  |  |
| 15 | 1.2.2.1 | Data QC 1 | 0.5h | 2003-08-03 03:30 | 2003-08-03 04:00 | 8 | 105.12d | 0d |  |
| 16 | 1.2.2.2 | Data QC 2 | 0.5h | 2003-08-03 10:00 | 2003-08-03 10:30 | 9 | 99.12d | 0d |  |
| 17 | 1.2.2.3 | Data QC3 | 0.5h | 2003-08-04 03:30 | 2003-08-04 04:00 | 10 | 102.12d | 0d |  |
| 18 | 1.2.2.4 | Data QC4 | 0.5h | 2003-08-04 10:00 | 2003-08-04 10:30 | 11 | 99.12d | 0d |  |
| 19 | 1.2.2.5 | Data QC5 | 0.5h | 2003-08-05 03:30 | 2003-08-05 04:00 | 12 | 99.94d | 0d |  |
| 20 | 1.2.2.6 | Data QC6 | 0.5h | 2003-08-05 10:00 | 2003-08-05 10:30 | 13 | 99.12d | 0d |  |
| 21 | 1.2.3 | **Objective Analysis** | 6.94d | 2003-08-03 04:00 | 2003-08-05 11:30 |  | 99.12d |  |  |
| 22 | 1.2.3.1 | OA 1 | 1h | 2003-08-03 04:00 | 2003-08-03 05:00 | 15 | 105.12d | 0d |  |
| 23 | 1.2.3.2 | OA 2 | 1h | 2003-08-03 10:30 | 2003-08-03 11:30 | 16 | 99.12d | 0d |  |
| 24 | 1.2.3.3 | OA 3 | 1h | 2003-08-04 04:00 | 2003-08-04 05:00 | 17 | 102.12d | 0d |  |
| 25 | 1.2.3.4 | OA 4 | 1h | 2003-08-04 10:30 | 2003-08-04 11:30 | 18 | 99.12d | 0d |  |
| 26 | 1.2.3.5 | OA 5 | 1h | 2003-08-05 04:00 | 2003-08-05 05:00 | 19 | 99.94d | 0d |  |
| 27 | 1.2.3.6 | OA 6 | 1h | 2003-08-05 10:30 | 2003-08-05 11:30 | 20 | 99.12d | 0d |  |

| ID | WBS | Task | Duration | Start | Finish | Predecessors | Total slack | Free slack |
| --- | --- | --- | --- | --- | --- | --- | --- | --- |
| 28 | 1.2.4 | **PE Initial** | 6.88d | 2003-08-03 05:00 | 2003-08-05 12:00 |  | 99.12d |  |
| 29 | 1.2.4.1 | PE Initial 1 | 0.5h | 2003-08-03 05:00 | 2003-08-03 05:30 | 22 | 105.12d | 0d |
| 30 | 1.2.4.2 | PE Initial 2 | 0.5h | 2003-08-03 11:30 | 2003-08-03 12:00 | 23 | 99.12d | 0d |
| 31 | 1.2.4.3 | PE Initial 3 | 0.5h | 2003-08-04 05:00 | 2003-08-04 05:30 | 24 | 102.12d | 0d |
| 32 | 1.2.4.4 | PE Initial 4 | 0.5h | 2003-08-04 11:30 | 2003-08-04 12:00 | 25 | 99.12d | 0d |
| 33 | 1.2.4.5 | PE Initial 5 | 0.5h | 2003-08-05 05:00 | 2003-08-05 05:30 | 26 | 99.94d | 0d |
| 34 | 1.2.4.6 | PE Initial 6 | 0.5h | 2003-08-05 11:30 | 2003-08-05 12:00 | 27 | 99.12d | 0d |
| 35 | 1.2.5 | **PE Forcing** | 6.88d | 2003-08-03 04:00 | 2003-08-05 11:00 |  | 99.25d |  |
| 36 | 1.2.5.1 | PE Forcing 1 | 0.5h | 2003-08-03 04:00 | 2003-08-03 04:30 | 15 | 105.25d | 0.12d |
| 37 | 1.2.5.2 | PE Forcing 2 | 0.5h | 2003-08-03 10:30 | 2003-08-03 11:00 | 16 | 99.25d | 0.12d |
| 38 | 1.2.5.3 | PE Forcing 3 | 0.5h | 2003-08-04 04:00 | 2003-08-04 04:30 | 17 | 102.25d | 0.12d |
| 39 | 1.2.5.4 | PE Forcing 4 | 0.5h | 2003-08-04 10:30 | 2003-08-04 11:00 | 18 | 99.25d | 0.12d |
| 40 | 1.2.5.5 | PE Forcint 5 | 0.5h | 2003-08-05 04:00 | 2003-08-05 04:30 | 19 | 100.06d | 0.12d |
| 41 | 1.2.5.6 | PE Forcing 6 | 0.5h | 2003-08-05 10:30 | 2003-08-05 11:00 | 20 | 99.25d | 0.12d |
| 42 | 1.2.6 | **PE Model** | 6.94d | 2003-08-03 05:30 | 2003-08-05 13:00 |  | 99.12d |  |
| 43 | 1.2.6.1 | PE Model 1 | 1h | 2003-08-03 05:30 | 2003-08-03 06:30 | 29, 36 | 105.12d | 0d |
| 44 | 1.2.6.2 | PE Model 2 | 1h | 2003-08-03 12:00 | 2003-08-03 13:00 | 30, 37 | 99.12d | 0d |
| 45 | 1.2.6.3 | PE Model 3 | 1h | 2003-08-04 05:30 | 2003-08-04 06:30 | 31, 38 | 102.12d | 0d |
| 46 | 1.2.6.4 | PE Model 4 | 1h | 2003-08-04 12:00 | 2003-08-04 13:00 | 32, 39 | 99.12d | 0d |
| 47 | 1.2.6.5 | PE Model 5 | 1h | 2003-08-05 05:30 | 2003-08-05 06:30 | 33, 40 | 99.94d | 0d |
| 48 | 1.2.6.6 | PE Model 6 | 1h | 2003-08-05 12:00 | 2003-08-05 13:00 | 34, 41 | 99.12d | 0d |
| 49 | 1.2.7 | **Model Quality Control** | 6.94d | 2003-08-03 06:30 | 2003-08-05 14:00 |  | 99.12d |  |
| 50 | 1.2.7.1 | Model QC 1 | 1h | 2003-08-03 06:30 | 2003-08-03 07:30 | 43 | 105.12d | 0d |
| 51 | 1.2.7.2 | Model QC 2 | 1h | 2003-08-03 13:00 | 2003-08-03 14:00 | 44 | 99.12d | 0d |
| 52 | 1.2.7.3 | Model QC 3 | 1h | 2003-08-04 06:30 | 2003-08-04 07:30 | 45 | 102.12d | 0d |
| 53 | 1.2.7.4 | Model QC 4 | 1h | 2003-08-04 13:00 | 2003-08-04 14:00 | 46 | 99.12d | 0d |
| 54 | 1.2.7.5 | Model QC 5 | 1h | 2003-08-05 06:30 | 2003-08-05 07:30 | 47 | 99.94d | 0d |
| 55 | 1.2.7.6 | Model QC 6 | 1h | 2003-08-05 13:00 | 2003-08-05 14:00 | 48 | 99.12d | 0d |

| ID | WBS | Task | Type | Duration | Start | Finish | Predecessors | Total slack | Free slack | Constraint |
| --- | --- | --- | --- | --- | --- | --- | --- | --- | --- | --- |
| 56 | 1.2.8 | **4D Fields** |  | 6.81d | 2003-08-03 07:30 | 2003-08-05 14:00 |  | 99.25d |  |  |
| 57 | 1.2.8.1 | 4DF 1 | milestone | 0h | 2003-08-03 07:30 | 2003-08-03 07:30 | 50 | 106.06d |  |  |
| 58 | 1.2.8.2 | 4DF 2 | milestone | 0h | 2003-08-03 14:00 | 2003-08-03 14:00 | 51 | 105.25d |  |  |
| 59 | 1.2.8.3 | 4DF 3 | milestone | 0h | 2003-08-04 07:30 | 2003-08-04 07:30 | 52 | 103.06d |  |  |
| 60 | 1.2.8.4 | 4DF 4 | milestone | 0h | 2003-08-04 14:00 | 2003-08-04 14:00 | 53 | 102.25d |  |  |
| 61 | 1.2.8.5 | 4DF 5 | milestone | 0h | 2003-08-05 07:30 | 2003-08-05 07:30 | 54 | 100.06d |  |  |
| 62 | 1.2.8.6 | 4DF 6 | milestone | 0h | 2003-08-05 14:00 | 2003-08-05 14:00 | 55 | 99.25d |  |  |
| 63 | 1.2.9 | **Graphical Products** |  | 6.94d | 2003-08-03 07:30 | 2003-08-05 15:00 |  | 99.12d |  |  |
| 64 | 1.2.9.1 | GP 1 |  | 1h | 2003-08-03 07:30 | 2003-08-03 08:30 | 50 | 105.94d | 0d |  |
| 65 | 1.2.9.2 | GP 2 |  | 1h | 2003-08-03 14:00 | 2003-08-03 15:00 | 51 | 99.12d | 0d |  |
| 66 | 1.2.9.3 | GP 3 |  | 1h | 2003-08-04 07:30 | 2003-08-04 08:30 | 52 | 102.94d | 0d |  |
| 67 | 1.2.9.4 | GP 4 |  | 1h | 2003-08-04 14:00 | 2003-08-04 15:00 | 53 | 99.12d | 0d |  |
| 68 | 1.2.9.5 | GP 5 |  | 1h | 2003-08-05 07:30 | 2003-08-05 08:30 | 54 | 99.94d | 0d |  |
| 69 | 1.2.9.6 | GP 6 |  | 1h | 2003-08-05 14:00 | 2003-08-05 15:00 | 55 | 99.12d | 0d |  |
| 70 | 1.2.10 | **Decision Aids to RTOC** |  | 6.81d | 2003-08-03 08:30 | 2003-08-05 15:00 |  | 99.12d |  |  |
| 71 | 1.2.10.1 | DA 1 | milestone | 0h | 2003-08-03 08:30 | 2003-08-03 08:30 | 64 | 105.94d |  |  |
| 72 | 1.2.10.2 | DA 2 | milestone | 0h | 2003-08-03 15:00 | 2003-08-03 15:00 | 65 | 99.12d | 0d |  |
| 73 | 1.2.10.3 | DA 3 | milestone | 0h | 2003-08-04 08:30 | 2003-08-04 08:30 | 66 | 102.94d |  |  |
| 74 | 1.2.10.4 | DA 4 | milestone | 0h | 2003-08-04 15:00 | 2003-08-04 15:00 | 67 | 99.12d | 0d |  |
| 75 | 1.2.10.5 | DA 5 | milestone | 0h | 2003-08-05 08:30 | 2003-08-05 08:30 | 68 | 99.94d |  |  |
| 76 | 1.2.10.6 | DA 6 | milestone | 0h | 2003-08-05 15:00 | 2003-08-05 15:00 | 69 | 99.12d |  |  |
| 77 | 2 | **ESSE Computation** |  | 11.81d | 2003-08-02 08:00 | 2003-08-06 06:30 |  | 97.19d |  |  |
| 78 | 2.1 | Field and Error Initialization |  | 48h | 2003-08-02 08:00 | 2003-08-04 08:00 |  | 97.19d | 0d | start no earlier than 2003-08-02 08:00 |
| 79 | 2.2 | **ESSE Cycle 1** |  | 5.81d | 2003-08-04 08:00 | 2003-08-06 06:30 | 78 | 97.19d |  |  |
| 80 | 2.2.1 | **ESSE Forecast** |  | 5d | 2003-08-04 08:00 | 2003-08-06 00:00 |  | 97.19d | 0d |  |
| 81 | 2.2.1.1 | **Physical only** |  | 2.5d | 2003-08-04 08:00 | 2003-08-05 04:00 |  | 99.69d |  |  |
| 82 | 2.2.1.1.1 | Error Sim for Data Assimilation |  | 20h | 2003-08-04 08:00 | 2003-08-05 04:00 |  | 99.69d |  |  |
| 83 | 2.2.1.1.2 | error simulation for adaptive sample |  | 5h | 2003-08-04 08:00 | 2003-08-04 13:00 |  | 101.56d |  |  |

| ID | WBS | Task | Duration | Start | Finish | Predecessors | Total slack | Free slack | Constraint |
| --- | --- | --- | --- | --- | --- | --- | --- | --- | --- |
| 84 | 2.2.1.2 | **Physical/Biological** | 5d | 2003-08-04 08:00 | 2003-08-06 00:00 |  | 97.19d |  |  |
| 85 | 2.2.1.2.1 | Error Sim for Data Assimilation | 40h | 2003-08-04 08:00 | 2003-08-06 00:00 |  | 97.19d |  |  |
| 86 | 2.2.1.2.2 | Error Sim for Adaptive Sampling | 10h | 2003-08-04 08:00 | 2003-08-04 18:00 |  | 100.94d |  |  |
| 87 | 2.2.2 | ESSE Adaptive Sampling | 2h | 2003-08-06 00:00 | 2003-08-06 02:00 | 80 | 97.19d | 0d |  |
| 88 | 2.2.3 | **ESSE Assimilation/Min error Variance** | 0.38d | 2003-08-06 02:00 | 2003-08-06 05:00 | 87, 80 | 97.19d | 0d |  |
| 89 | 2.2.3.1 | Physical Only | 2h | 2003-08-06 02:00 | 2003-08-06 04:00 |  | 97.31d |  |  |
| 90 | 2.2.3.2 | Physical/Biological | 3h | 2003-08-06 02:00 | 2003-08-06 05:00 |  | 97.19d |  |  |
| 91 | 2.2.4 | **ESSE Error Learning** | 0.19d | 2003-08-06 05:00 | 2003-08-06 06:30 | 87, 88 | 97.19d |  |  |
| 92 | 2.2.4.1 | Physical Only | 1h | 2003-08-06 05:00 | 2003-08-06 06:00 |  | 97.25d |  |  |
| 93 | 2.2.4.2 | Physical/Biological | 1.5h | 2003-08-06 05:00 | 2003-08-06 06:30 |  | 97.19d |  |  |
| 94 | 3 | **Super Ensemble Computation** | 6.06d | 2003-08-03 08:00 | 2003-08-05 08:30 |  | 99.06d |  |  |
| 95 | 3.1 | Super Ensemble Computation 1 | 0.5h | 2003-08-03 08:00 | 2003-08-03 08:30 | 3, 50 | 105.06d | 0d | start no earlier than 2003-08-03 08:00 |
| 96 | 3.2 | Super Ensemble Computation 2 | 0.5h | 2003-08-04 08:00 | 2003-08-04 08:30 | 4, 51 | 102.06d | 0d | start no earlier than 2003-08-04 08:00 |
| 97 | 3.3 | Super Ensemble Computation 3 | 0.5h | 2003-08-05 08:00 | 2003-08-05 08:30 | 5, 52 | 99.06d | 0d | start no earlier than 2003-08-05 08:00 |
| 98 | 4 | **LCS Computation** | 102.31d | 2003-08-03 08:30 | 2003-09-06 11:00 |  | 3.12d |  |  |
| 99 | 4.1 | LCS Computation 1 | 3h | 2003-08-03 08:30 | 2003-08-03 11:30 | 95 | 105.06d | 0d | start no earlier than 2003-08-02 08:00 |
| 100 | 4.2 | LCS Computation 2 | 3h | 2003-08-04 08:30 | 2003-08-04 11:30 | 96 | 102.06d | 0d | start no earlier than 2003-08-03 08:00 |
| 101 | 4.3 | LCS Computation 3 | 3h | 2003-08-05 08:30 | 2003-08-05 11:30 | 97 | 99.06d | 0d | start no earlier than 2003-08-04 08:00 |
| 102 | 4.4 | LCS Computation 4 | 3h | 2003-08-05 08:00 | 2003-08-05 11:00 |  | 99.12d | 2.62d | start no earlier than 2003-08-05 08:00 |
| 103 | 4.5 | LCS Computation 5 | 3h | 2003-08-06 08:00 | 2003-08-06 11:00 |  | 96.12d | 2.62d | start no earlier than 2003-08-06 08:00 |
| 104 | 4.6 | LCS Computation 6 | 3h | 2003-08-07 08:00 | 2003-08-07 11:00 |  | 93.12d | 2.62d | start no earlier than 2003-08-07 08:00 |
| 105 | 4.7 | LCS Computation 7 | 3h | 2003-08-08 08:00 | 2003-08-08 11:00 |  | 90.12d | 2.62d | start no earlier than 2003-08-08 08:00 |
| 106 | 4.8 | LCS Computation 8 | 3h | 2003-08-09 08:00 | 2003-08-09 11:00 |  | 87.12d | 2.62d | start no earlier than 2003-08-09 08:00 |
| 107 | 4.9 | LCS Computation 9 | 3h | 2003-08-10 08:00 | 2003-08-10 11:00 |  | 84.12d | 2.62d | start no earlier than 2003-08-10 08:00 |
| 108 | 4.10 | LCS Computation 10 | 3h | 2003-08-11 08:00 | 2003-08-11 11:00 |  | 81.12d | 2.62d | start no earlier than 2003-08-11 08:00 |
| 109 | 4.11 | LCS Computation 11 | 3h | 2003-08-12 08:00 | 2003-08-12 11:00 |  | 78.12d | 2.62d | start no earlier than 2003-08-12 08:00 |
| 110 | 4.12 | LCS Computation 12 | 3h | 2003-08-13 08:00 | 2003-08-13 11:00 |  | 75.12d | 2.62d | start no earlier than 2003-08-13 08:00 |
| 111 | 4.13 | LCS Computation 13 | 3h | 2003-08-14 08:00 | 2003-08-14 11:00 |  | 72.12d | 2.62d | start no earlier than 2003-08-14 08:00 |
| 112 | 4.14 | LCS Computation 14 | 3h | 2003-08-15 08:00 | 2003-08-15 11:00 |  | 69.12d | 2.62d | start no earlier than 2003-08-15 08:00 |
| 113 | 4.15 | LCS Computation 15 | 3h | 2003-08-16 08:00 | 2003-08-16 11:00 |  | 66.12d | 2.62d | start no earlier than 2003-08-16 08:00 |
| 114 | 4.16 | LCS Computation 16 | 3h | 2003-08-17 08:00 | 2003-08-17 11:00 |  | 63.12d | 2.62d | start no earlier than 2003-08-17 08:00 |
| 115 | 4.17 | LCS Computation 17 | 3h | 2003-08-18 08:00 | 2003-08-18 11:00 |  | 60.12d | 2.62d | start no earlier than 2003-08-18 08:00 |
| 116 | 4.18 | LCS Computation 18 | 3h | 2003-08-19 08:00 | 2003-08-19 11:00 |  | 57.12d | 2.62d | start no earlier than 2003-08-19 08:00 |
| 117 | 4.19 | LCS Computation 19 | 3h | 2003-08-20 08:00 | 2003-08-20 11:00 |  | 54.12d | 2.62d | start no earlier than 2003-08-20 08:00 |
| 118 | 4.20 | LCS Computation 20 | 3h | 2003-08-21 08:00 | 2003-08-21 11:00 |  | 51.12d | 2.62d | start no earlier than 2003-08-21 08:00 |
| 119 | 4.21 | LCS Computation 21 | 3h | 2003-08-22 08:00 | 2003-08-22 11:00 |  | 48.12d | 2.62d | start no earlier than 2003-08-22 08:00 |
| 120 | 4.22 | LCS Computation 22 | 3h | 2003-08-23 08:00 | 2003-08-23 11:00 |  | 45.12d | 2.62d | start no earlier than 2003-08-23 08:00 |
| 121 | 4.23 | LCS Computation 23 | 3h | 2003-08-24 08:00 | 2003-08-24 11:00 |  | 42.12d | 2.62d | start no earlier than 2003-08-24 08:00 |
| 122 | 4.24 | LCS Computation 24 | 3h | 2003-08-25 08:00 | 2003-08-25 11:00 |  | 39.12d | 2.62d | start no earlier than 2003-08-25 08:00 |
| 123 | 4.25 | LCS Computation 25 | 3h | 2003-08-26 08:00 | 2003-08-26 11:00 |  | 36.12d | 2.62d | start no earlier than 2003-08-26 08:00 |
| 124 | 4.26 | LCS Computation 26 | 3h | 2003-08-27 08:00 | 2003-08-27 11:00 |  | 33.12d | 2.62d | start no earlier than 2003-08-27 08:00 |
| 125 | 4.27 | LCS Computation 27 | 3h | 2003-08-28 08:00 | 2003-08-28 11:00 |  | 30.12d | 2.62d | start no earlier than 2003-08-28 08:00 |
| 126 | 4.28 | LCS Computation 28 | 3h | 2003-08-29 08:00 | 2003-08-29 11:00 |  | 27.12d | 2.62d | start no earlier than 2003-08-29 08:00 |
| 127 | 4.29 | LCS Computation 29 | 3h | 2003-08-30 08:00 | 2003-08-30 11:00 |  | 24.12d | 2.62d | start no earlier than 2003-08-30 08:00 |
| 128 | 4.30 | LCS Computation 30 | 3h | 2003-08-31 08:00 | 2003-08-31 11:00 |  | 21.12d | 2.62d | start no earlier than 2003-08-31 08:00 |
| 129 | 4.31 | LCS Computation 31 | 3h | 2003-09-01 08:00 | 2003-09-01 11:00 |  | 18.12d | 2.62d | start no earlier than 2003-09-01 08:00 |
| 130 | 4.32 | LCS Computation 32 | 3h | 2003-09-02 08:00 | 2003-09-02 11:00 |  | 15.12d | 2.62d | start no earlier than 2003-09-02 08:00 |
| 131 | 4.33 | LCS Computation 33 | 3h | 2003-09-03 08:00 | 2003-09-03 11:00 |  | 12.12d | 2.62d | start no earlier than 2003-09-03 08:00 |
| 132 | 4.34 | LCS Computation 34 | 3h | 2003-09-04 08:00 | 2003-09-04 11:00 |  | 9.12d | 2.62d | start no earlier than 2003-09-04 08:00 |
| 133 | 4.35 | LCS Computation 35 | 3h | 2003-09-05 08:00 | 2003-09-05 11:00 |  | 6.12d | 2.62d | start no earlier than 2003-09-05 08:00 |
| 134 | 4.36 | LCS Computation 36 | 3h | 2003-09-06 08:00 | 2003-09-06 11:00 |  | 3.12d | 2.62d | start no earlier than 2003-09-06 08:00 |

| ID | WBS | Task | Duration | Start | Finish | Predecessors | Total slack | Free slack | Constraint |
| --- | --- | --- | --- | --- | --- | --- | --- | --- | --- |
| 135 | 5 | **RTOC Deliberation** | 104.81d | 2003-08-03 11:30 | 2003-09-07 10:00 |  | 0.5d |  |  |
| 136 | 5.1 | RTOC Deliberation 1 | 2h | 2003-08-03 11:30 | 2003-08-03 13:30 | 99 | 105.06d | 0d | start no earlier than 2003-08-03 08:00 |
| 137 | 5.2 | RTOC Deliberation 2 | 2h | 2003-08-04 11:30 | 2003-08-04 13:30 | 100 | 102.06d | 0d | start no earlier than 2003-08-04 08:00 |
| 138 | 5.3 | RTOC Deliberation 3 | 2h | 2003-08-05 11:30 | 2003-08-05 13:30 | 101 | 99.06d | 0d | start no earlier than 2003-08-05 08:00 |
| 139 | 5.4 | RTOC Deliberation 4 | 2h | 2003-08-06 08:00 | 2003-08-06 10:00 | 102 | 96.5d | 0d | start no earlier than 2003-08-06 08:00 |
| 140 | 5.5 | RTOC Deliberation 5 | 2h | 2003-08-07 08:00 | 2003-08-07 10:00 | 103 | 93.5d | 0d | start no earlier than 2003-08-07 08:00 |
| 141 | 5.6 | RTOC Deliberation 6 | 2h | 2003-08-08 08:00 | 2003-08-08 10:00 | 104 | 90.5d | 0d | start no earlier than 2003-08-08 08:00 |
| 142 | 5.7 | RTOC Deliberation 7 | 2h | 2003-08-09 08:00 | 2003-08-09 10:00 | 105 | 87.5d | 0d | start no earlier than 2003-08-09 08:00 |
| 143 | 5.8 | RTOC Deliberation 8 | 2h | 2003-08-10 08:00 | 2003-08-10 10:00 | 106 | 84.5d | 0d | start no earlier than 2003-08-10 08:00 |
| 144 | 5.9 | RTOC Deliberation 9 | 2h | 2003-08-11 08:00 | 2003-08-11 10:00 | 107 | 81.5d | 0d | start no earlier than 2003-08-11 08:00 |
| 145 | 5.10 | RTOC Deliberation 10 | 2h | 2003-08-12 08:00 | 2003-08-12 10:00 | 108 | 78.5d | 0d | start no earlier than 2003-08-12 08:00 |
| 146 | 5.11 | RTOC Deliberation 11 | 2h | 2003-08-13 08:00 | 2003-08-13 10:00 | 109 | 75.5d | 0d | start no earlier than 2003-08-13 08:00 |
| 147 | 5.12 | RTOC Deliberation 12 | 2h | 2003-08-14 08:00 | 2003-08-14 10:00 | 110 | 72.5d | 0d | start no earlier than 2003-08-14 08:00 |
| 148 | 5.13 | RTOC Deliberation 13 | 2h | 2003-08-15 08:00 | 2003-08-15 10:00 | 111 | 69.5d | 0d | start no earlier than 2003-08-15 08:00 |
| 149 | 5.14 | RTOC Deliberation 14 | 2h | 2003-08-16 08:00 | 2003-08-16 10:00 | 112 | 66.5d | 0d | start no earlier than 2003-08-16 08:00 |
| 150 | 5.15 | RTOC Deliberation 15 | 2h | 2003-08-17 08:00 | 2003-08-17 10:00 | 113 | 63.5d | 0d | start no earlier than 2003-08-17 08:00 |
| 151 | 5.16 | RTOC Deliberation 16 | 2h | 2003-08-18 08:00 | 2003-08-18 10:00 | 114 | 60.5d | 0d | start no earlier than 2003-08-18 08:00 |
| 152 | 5.17 | RTOC Deliberation 17 | 2h | 2003-08-19 08:00 | 2003-08-19 10:00 | 115 | 57.5d | 0d | start no earlier than 2003-08-19 08:00 |
| 153 | 5.18 | RTOC Deliberation 18 | 2h | 2003-08-20 08:00 | 2003-08-20 10:00 | 116 | 54.5d | 0d | start no earlier than 2003-08-20 08:00 |
| 154 | 5.19 | RTOC Deliberation 19 | 2h | 2003-08-21 08:00 | 2003-08-21 10:00 | 117 | 51.5d | 0d | start no earlier than 2003-08-21 08:00 |
| 155 | 5.20 | RTOC Deliberation 20 | 2h | 2003-08-22 08:00 | 2003-08-22 10:00 | 118 | 48.5d | 0d | start no earlier than 2003-08-22 08:00 |
| 156 | 5.21 | RTOC Deliberation 21 | 2h | 2003-08-23 08:00 | 2003-08-23 10:00 | 119 | 45.5d | 0d | start no earlier than 2003-08-23 08:00 |
| 157 | 5.22 | RTOC Deliberation 22 | 2h | 2003-08-24 08:00 | 2003-08-24 10:00 | 120 | 42.5d | 0d | start no earlier than 2003-08-24 08:00 |
| 158 | 5.23 | RTOC Deliberation 23 | 2h | 2003-08-25 08:00 | 2003-08-25 10:00 | 121 | 39.5d | 0d | start no earlier than 2003-08-25 08:00 |
| 159 | 5.24 | RTOC Deliberation 24 | 2h | 2003-08-26 08:00 | 2003-08-26 10:00 | 122 | 36.5d | 0d | start no earlier than 2003-08-26 08:00 |
| 160 | 5.25 | RTOC Deliberation 25 | 2h | 2003-08-27 08:00 | 2003-08-27 10:00 | 123 | 33.5d | 0d | start no earlier than 2003-08-27 08:00 |
| 161 | 5.26 | RTOC Deliberation 26 | 2h | 2003-08-28 08:00 | 2003-08-28 10:00 | 124 | 30.5d | 0d | start no earlier than 2003-08-28 08:00 |
| 162 | 5.27 | RTOC Deliberation 27 | 2h | 2003-08-29 08:00 | 2003-08-29 10:00 | 125 | 27.5d | 0d | start no earlier than 2003-08-29 08:00 |
| 163 | 5.28 | RTOC Deliberation 28 | 2h | 2003-08-30 08:00 | 2003-08-30 10:00 | 126 | 24.5d | 0d | start no earlier than 2003-08-30 08:00 |
| 164 | 5.29 | RTOC Deliberation 29 | 2h | 2003-08-31 08:00 | 2003-08-31 10:00 | 127 | 21.5d | 0d | start no earlier than 2003-08-31 08:00 |
| 165 | 5.30 | RTOC Deliberation 30 | 2h | 2003-09-01 08:00 | 2003-09-01 10:00 | 128 | 18.5d | 0d | start no earlier than 2003-09-01 08:00 |
| 166 | 5.31 | RTOC Deliberation 31 | 2h | 2003-09-02 08:00 | 2003-09-02 10:00 | 129 | 15.5d | 0d | start no earlier than 2003-09-02 08:00 |
| 167 | 5.32 | RTOC Deliberation 32 | 2h | 2003-09-03 08:00 | 2003-09-03 10:00 | 130 | 12.5d | 0d | start no earlier than 2003-09-03 08:00 |
| 168 | 5.33 | RTOC Deliberation 33 | 2h | 2003-09-04 08:00 | 2003-09-04 10:00 | 131 | 9.5d | 0d | start no earlier than 2003-09-04 08:00 |
| 169 | 5.34 | RTOC Deliberation 34 | 2h | 2003-09-05 08:00 | 2003-09-05 10:00 | 132 | 6.5d | 0d | start no earlier than 2003-09-05 08:00 |
| 170 | 5.35 | RTOC Deliberation 35 | 2h | 2003-09-06 08:00 | 2003-09-06 10:00 | 133 | 3.5d | 0d | start no earlier than 2003-09-06 08:00 |
| 171 | 5.36 | RTOC Deliberation 36 | 2h | 2003-09-07 08:00 | 2003-09-07 10:00 | 134 | 0.5d | 0d | start no earlier than 2003-09-07 08:00 |

Notes:
- 135: RTOC Deliberations

| ID | WBS | Task | Duration | Start | Finish | Predecessors | Total slack | Constraint |
| --- | --- | --- | --- | --- | --- | --- | --- | --- |
| 172 | 6 | **AS Vehicle Tasking** | 104.81d | 2003-08-03 13:30 | 2003-09-07 12:00 |  | 0.5d |  |
| 173 | 6.1 | AS Vehicle Tasking 1 | 2h | 2003-08-03 13:30 | 2003-08-03 15:30 | 136 | 105.06d | start no earlier than 2003-08-03 08:00 |
| 174 | 6.2 | AS Vehicle Tasking 2 | 2h | 2003-08-04 13:30 | 2003-08-04 15:30 | 137 | 102.06d | start no earlier than 2003-08-04 08:00 |
| 175 | 6.3 | AS Vehicle Tasking 3 | 2h | 2003-08-05 13:30 | 2003-08-05 15:30 | 138 | 99.06d | start no earlier than 2003-08-05 08:00 |
| 176 | 6.4 | AS Vehicle Tasking 4 | 2h | 2003-08-06 10:00 | 2003-08-06 12:00 | 139 | 96.5d | start no earlier than 2003-08-06 08:00 |
| 177 | 6.5 | AS Vehicle Tasking 5 | 2h | 2003-08-07 10:00 | 2003-08-07 12:00 | 140 | 93.5d | start no earlier than 2003-08-07 08:00 |
| 178 | 6.6 | AS Vehicle Tasking 6 | 2h | 2003-08-08 10:00 | 2003-08-08 12:00 | 141 | 90.5d | start no earlier than 2003-08-08 08:00 |
| 179 | 6.7 | AS Vehicle Tasking 7 | 2h | 2003-08-09 10:00 | 2003-08-09 12:00 | 142 | 87.5d | start no earlier than 2003-08-09 08:00 |
| 180 | 6.8 | AS Vehicle Tasking 8 | 2h | 2003-08-10 10:00 | 2003-08-10 12:00 | 143 | 84.5d | start no earlier than 2003-08-10 08:00 |
| 181 | 6.9 | AS Vehicle Tasking 9 | 2h | 2003-08-11 10:00 | 2003-08-11 12:00 | 144 | 81.5d | start no earlier than 2003-08-11 08:00 |
| 182 | 6.10 | AS Vehicle Tasking 10 | 2h | 2003-08-12 10:00 | 2003-08-12 12:00 | 145 | 78.5d | start no earlier than 2003-08-12 08:00 |
| 183 | 6.11 | AS Vehicle Tasking 11 | 2h | 2003-08-13 10:00 | 2003-08-13 12:00 | 146 | 75.5d | start no earlier than 2003-08-13 08:00 |
| 184 | 6.12 | AS Vehicle Tasking 12 | 2h | 2003-08-14 10:00 | 2003-08-14 12:00 | 147 | 72.5d | start no earlier than 2003-08-14 08:00 |
| 185 | 6.13 | AS Vehicle Tasking 13 | 2h | 2003-08-15 10:00 | 2003-08-15 12:00 | 148 | 69.5d | start no earlier than 2003-08-15 08:00 |
| 186 | 6.14 | AS Vehicle Tasking 14 | 2h | 2003-08-16 10:00 | 2003-08-16 12:00 | 149 | 66.5d | start no earlier than 2003-08-16 08:00 |
| 187 | 6.15 | AS Vehicle Tasking 15 | 2h | 2003-08-17 10:00 | 2003-08-17 12:00 | 150 | 63.5d | start no earlier than 2003-08-17 08:00 |
| 188 | 6.16 | AS Vehicle Tasking 16 | 2h | 2003-08-18 10:00 | 2003-08-18 12:00 | 151 | 60.5d | start no earlier than 2003-08-18 08:00 |
| 189 | 6.17 | AS Vehicle Tasking 17 | 2h | 2003-08-19 10:00 | 2003-08-19 12:00 | 152 | 57.5d | start no earlier than 2003-08-19 08:00 |
| 190 | 6.18 | AS Vehicle Tasking 18 | 2h | 2003-08-20 10:00 | 2003-08-20 12:00 | 153 | 54.5d | start no earlier than 2003-08-20 08:00 |
| 191 | 6.19 | AS Vehicle Tasking 19 | 2h | 2003-08-21 10:00 | 2003-08-21 12:00 | 154 | 51.5d | start no earlier than 2003-08-21 08:00 |
| 192 | 6.20 | AS Vehicle Tasking 20 | 2h | 2003-08-22 10:00 | 2003-08-22 12:00 | 155 | 48.5d | start no earlier than 2003-08-22 08:00 |
| 193 | 6.21 | AS Vehicle Tasking 21 | 2h | 2003-08-23 10:00 | 2003-08-23 12:00 | 156 | 45.5d | start no earlier than 2003-08-23 08:00 |
| 194 | 6.22 | AS Vehicle Tasking 22 | 2h | 2003-08-24 10:00 | 2003-08-24 12:00 | 157 | 42.5d | start no earlier than 2003-08-24 08:00 |
| 195 | 6.23 | AS Vehicle Tasking 23 | 2h | 2003-08-25 10:00 | 2003-08-25 12:00 | 158 | 39.5d | start no earlier than 2003-08-25 08:00 |
| 196 | 6.24 | AS Vehicle Tasking 24 | 2h | 2003-08-26 10:00 | 2003-08-26 12:00 | 159 | 36.5d | start no earlier than 2003-08-26 08:00 |
| 197 | 6.25 | AS Vehicle Tasking 25 | 2h | 2003-08-27 10:00 | 2003-08-27 12:00 | 160 | 33.5d | start no earlier than 2003-08-27 08:00 |
| 198 | 6.26 | AS Vehicle Tasking 26 | 2h | 2003-08-28 10:00 | 2003-08-28 12:00 | 161 | 30.5d | start no earlier than 2003-08-28 08:00 |
| 199 | 6.27 | AS Vehicle Tasking 27 | 2h | 2003-08-29 10:00 | 2003-08-29 12:00 | 162 | 27.5d | start no earlier than 2003-08-29 08:00 |
| 200 | 6.28 | AS Vehicle Tasking 28 | 2h | 2003-08-30 10:00 | 2003-08-30 12:00 | 163 | 24.5d | start no earlier than 2003-08-30 08:00 |
| 201 | 6.29 | AS Vehicle Tasking 29 | 2h | 2003-08-31 10:00 | 2003-08-31 12:00 | 164 | 21.5d | start no earlier than 2003-08-31 08:00 |
| 202 | 6.30 | AS Vehicle Tasking 30 | 2h | 2003-09-01 10:00 | 2003-09-01 12:00 | 165 | 18.5d | start no earlier than 2003-09-01 08:00 |
| 203 | 6.31 | AS Vehicle Tasking 31 | 2h | 2003-09-02 10:00 | 2003-09-02 12:00 | 166 | 15.5d | start no earlier than 2003-09-02 08:00 |
| 204 | 6.32 | AS Vehicle Tasking 32 | 2h | 2003-09-03 10:00 | 2003-09-03 12:00 | 167 | 12.5d | start no earlier than 2003-09-03 08:00 |
| 205 | 6.33 | AS Vehicle Tasking 33 | 2h | 2003-09-04 10:00 | 2003-09-04 12:00 | 168 | 9.5d | start no earlier than 2003-09-04 08:00 |
| 206 | 6.34 | AS Vehicle Tasking 34 | 2h | 2003-09-05 10:00 | 2003-09-05 12:00 | 169 | 6.5d | start no earlier than 2003-09-05 08:00 |
| 207 | 6.35 | AS Vehicle Tasking 35 | 2h | 2003-09-06 10:00 | 2003-09-06 12:00 | 170 | 3.5d | start no earlier than 2003-09-06 08:00 |
| 208 | 6.36 | AS Vehicle Tasking 36 | 2h | 2003-09-07 10:00 | 2003-09-07 12:00 | 171 | 0.5d | start no earlier than 2003-09-07 08:00 |

| ID | WBS | Task | Type | Duration | Start | Finish | Predecessors | Baseline start | Baseline finish | Baseline duration | Total slack | Free slack | Constraint |
| --- | --- | --- | --- | --- | --- | --- | --- | --- | --- | --- | --- | --- | --- |
| 209 | 7 | **AS Glider Operations** |  | 9.76d | 2003-08-02 10:00 | 2003-08-05 16:05 |  |  |  |  | 98.99d |  |  |
| 210 | 7.1 | **AS Glider Data Surfacing** |  | 9.73d | 2003-08-02 10:00 | 2003-08-05 15:50 |  | 2003-07-14 10:10 | 2003-08-02 10:55 | 57.09d | 98.99d |  |  |
| 211 | 7.1.1 | AS Glider Surfacing 1 | milestone | 20min | 2003-08-02 10:00 | 2003-08-02 10:20 |  | 2003-08-02 08:00 | 2003-08-02 08:20 | 20min | 98.99d | 0d | start no earlier than 2003-08-02 10:00 |
| 212 | 7.1.2 | AS Observation Data QC1 |  | 5min | 2003-08-02 10:20 | 2003-08-02 10:25 | 211 | 2003-08-02 08:20 | 2003-08-02 08:25 | 5min | 98.99d | 0d |  |
| 213 | 7.1.3 | AS Feedback Control 1 |  | 10min | 2003-08-02 10:25 | 2003-08-02 10:35 | 212 |  |  |  | 98.99d | 0d |  |
| 214 | 7.1.4 | AS Glider Dive 1 | milestone | 0h | 2003-08-02 10:35 | 2003-08-02 10:35 | 213 | 2003-08-02 08:35 | 2003-08-02 08:35 | 0h | 98.99d | 0d |  |
| 215 | 7.1.5 | AS Glider Surfacing 2 | milestone | 20min | 2003-08-02 12:35 | 2003-08-02 12:55 | 214FS+2h |  |  |  | 98.99d | 0d |  |
| 216 | 7.1.6 | AS Observation Data QC2 |  | 5min | 2003-08-02 12:55 | 2003-08-02 13:00 | 215 |  |  |  | 98.99d | 0d |  |
| 217 | 7.1.7 | AS Feedback Control 2 |  | 10min | 2003-08-02 13:00 | 2003-08-02 13:10 | 216 |  |  |  | 98.99d | 0d |  |
| 218 | 7.1.8 | AS Glider Dive 2 | milestone | 0h | 2003-08-02 13:10 | 2003-08-02 13:10 | 217 |  |  |  | 98.99d | 0d |  |
| 219 | 7.1.9 | AS Glider Surfacing 3 | milestone | 20min | 2003-08-02 15:10 | 2003-08-02 15:30 | 218FS+2h |  |  |  | 98.99d | 0d |  |
| 220 | 7.1.10 | AS Observation Data QC3 |  | 5min | 2003-08-02 15:30 | 2003-08-02 15:35 | 219 |  |  |  | 98.99d | 0d |  |
| 221 | 7.1.11 | AS Feedback Control 2 |  | 10min | 2003-08-02 15:35 | 2003-08-02 15:45 | 220 |  |  |  | 98.99d | 0d |  |
| 222 | 7.1.12 | AS Glider Dive 2 | milestone | 0h | 2003-08-02 15:45 | 2003-08-02 15:45 | 221 |  |  |  | 98.99d | 0d |  |
| 223 | 7.1.13 | AS Glider Surfacing 4 | milestone | 20min | 2003-08-02 17:45 | 2003-08-02 18:05 | 222FS+2h |  |  |  | 98.99d | 0d |  |
| 224 | 7.1.14 | AS Glider Surfacing 5 | milestone | 20min | 2003-08-02 20:20 | 2003-08-02 20:40 | 310FS+2h |  |  |  | 98.99d | 0d |  |
| 225 | 7.1.15 | AS Glider Surfacing 6 | milestone | 20min | 2003-08-02 22:55 | 2003-08-02 23:15 | 311FS+2h |  |  |  | 98.99d | 0d |  |
| 226 | 7.1.16 | AS Glider Surfacing 7 | milestone | 20min | 2003-08-03 01:30 | 2003-08-03 01:50 | 312FS+2h |  |  |  | 98.99d | 0d |  |
| 227 | 7.1.17 | AS Glider Surfacing 8 | milestone | 20min | 2003-08-03 04:05 | 2003-08-03 04:25 | 313FS+2h |  |  |  | 98.99d | 0d |  |
| 228 | 7.1.18 | AS Glider Surfacing 9 | milestone | 20min | 2003-08-03 06:40 | 2003-08-03 07:00 | 314FS+2h |  |  |  | 98.99d | 0d |  |
| 229 | 7.1.19 | AS Glider Surfacing 10 | milestone | 20min | 2003-08-03 09:15 | 2003-08-03 09:35 | 315FS+2h |  |  |  | 98.99d | 0d |  |
| 230 | 7.1.20 | AS Glider Surfacing 11 | milestone | 20min | 2003-08-03 11:50 | 2003-08-03 12:10 | 316FS+2h |  |  |  | 98.99d | 0d |  |
| 231 | 7.1.21 | AS Glider Surfacing 12 | milestone | 20min | 2003-08-03 14:25 | 2003-08-03 14:45 | 317FS+2h |  |  |  | 98.99d | 0d |  |
| 232 | 7.1.22 | AS Glider Surfacing 13 | milestone | 20min | 2003-08-03 17:00 | 2003-08-03 17:20 | 318FS+2h |  |  |  | 98.99d | 0d |  |
| 233 | 7.1.23 | AS Glider Surfacing 14 | milestone | 20min | 2003-08-03 19:35 | 2003-08-03 19:55 | 319FS+2h |  |  |  | 98.99d | 0d |  |
| 234 | 7.1.24 | AS Glider Surfacing 15 | milestone | 20min | 2003-08-03 22:10 | 2003-08-03 22:30 | 320FS+2h |  |  |  | 98.99d | 0d |  |
| 235 | 7.1.25 | AS Glider Surfacing 16 | milestone | 20min | 2003-08-04 00:45 | 2003-08-04 01:05 | 321FS+2h |  |  |  | 98.99d | 0d |  |
| 236 | 7.1.26 | AS Glider Surfacing 16 | milestone | 20min | 2003-08-04 03:20 | 2003-08-04 03:40 | 322FS+2h |  |  |  | 98.99d | 0d |  |
| 237 | 7.1.27 | AS Glider Surfacing 16 | milestone | 20min | 2003-08-04 05:55 | 2003-08-04 06:15 | 323FS+2h |  |  |  | 98.99d | 0d |  |
| 238 | 7.1.28 | AS Glider Surfacing 16 | milestone | 20min | 2003-08-04 08:30 | 2003-08-04 08:50 | 324FS+2h |  |  |  | 98.99d | 0d |  |
| 239 | 7.1.29 | AS Glider Surfacing 16 | milestone | 20min | 2003-08-04 11:05 | 2003-08-04 11:25 | 325FS+2h |  |  |  | 98.99d | 0d |  |
| 240 | 7.1.30 | AS Glider Surfacing 16 | milestone | 20min | 2003-08-04 13:40 | 2003-08-04 14:00 | 326FS+2h |  |  |  | 98.99d | 0d |  |
| 241 | 7.1.31 | AS Glider Surfacing 16 | milestone | 20min | 2003-08-04 16:15 | 2003-08-04 16:35 | 327FS+2h |  |  |  | 98.99d | 0d |  |
| 242 | 7.1.32 | AS Glider Surfacing 16 | milestone | 20min | 2003-08-04 18:50 | 2003-08-04 19:10 | 328FS+2h |  |  |  | 98.99d | 0d |  |
| 243 | 7.1.33 | AS Glider Surfacing 16 | milestone | 20min | 2003-08-04 21:25 | 2003-08-04 21:45 | 329FS+2h |  |  |  | 98.99d | 0d |  |
| 244 | 7.1.34 | AS Glider Surfacing 16 | milestone | 20min | 2003-08-05 00:00 | 2003-08-05 00:20 | 330FS+2h |  |  |  | 98.99d | 0d |  |
| 245 | 7.1.35 | AS Glider Surfacing 16 | milestone | 20min | 2003-08-05 02:35 | 2003-08-05 02:55 | 331FS+2h |  |  |  | 98.99d | 0d |  |
| 246 | 7.1.36 | AS Glider Surfacing 16 | milestone | 20min | 2003-08-05 05:10 | 2003-08-05 05:30 | 332FS+2h |  |  |  | 98.99d | 0d |  |
| 247 | 7.1.37 | AS Glider Surfacing 16 | milestone | 20min | 2003-08-05 07:45 | 2003-08-05 08:05 | 333FS+2h |  |  |  | 98.99d | 0d |  |
| 248 | 7.1.38 | AS Glider Surfacing 16 | milestone | 20min | 2003-08-05 10:20 | 2003-08-05 10:40 | 334FS+2h |  |  |  | 98.99d | 0d |  |
| 249 | 7.1.39 | AS Glider Surfacing 16 | milestone | 20min | 2003-08-05 12:55 | 2003-08-05 13:15 | 335FS+2h |  |  |  | 98.99d | 0d |  |
| 250 | 7.1.40 | AS Glider Surfacing 16 | milestone | 20min | 2003-08-05 15:30 | 2003-08-05 15:50 | 336FS+2h |  |  |  | 98.99d | 0d |  |

| ID | WBS | Task | Duration | Start | Finish | Predecessors | Baseline start | Baseline finish | Baseline duration | Total slack | Free slack |
| --- | --- | --- | --- | --- | --- | --- | --- | --- | --- | --- | --- |
| 251 | 7.2 | **AS Observation Data Avail** | 8.73d | 2003-08-02 18:05 | 2003-08-05 15:55 |  | 2003-08-02 08:20 | 2003-08-02 08:25 | 0.01d | 98.99d |  |
| 252 | 7.2.1 | AS Observation Data QC4 | 5min | 2003-08-02 18:05 | 2003-08-02 18:10 | 223 |  |  |  | 98.99d | 0d |
| 253 | 7.2.2 | AS Observation Data QC5 | 5min | 2003-08-02 20:40 | 2003-08-02 20:45 | 224 |  |  |  | 98.99d | 0d |
| 254 | 7.2.3 | AS Observation Data QC6 | 5min | 2003-08-02 23:15 | 2003-08-02 23:20 | 225 |  |  |  | 98.99d | 0d |
| 255 | 7.2.4 | AS Observation Data QC7 | 5min | 2003-08-03 01:50 | 2003-08-03 01:55 | 226 |  |  |  | 98.99d | 0d |
| 256 | 7.2.5 | AS Observation Data QC8 | 5min | 2003-08-03 04:25 | 2003-08-03 04:30 | 227 |  |  |  | 98.99d | 0d |
| 257 | 7.2.6 | AS Observation Data QC9 | 5min | 2003-08-03 07:00 | 2003-08-03 07:05 | 228 |  |  |  | 98.99d | 0d |
| 258 | 7.2.7 | AS Observation Data QC10 | 5min | 2003-08-03 09:35 | 2003-08-03 09:40 | 229 |  |  |  | 98.99d | 0d |
| 259 | 7.2.8 | AS Observation Data QC11 | 5min | 2003-08-03 12:10 | 2003-08-03 12:15 | 230 |  |  |  | 98.99d | 0d |
| 260 | 7.2.9 | AS Observation Data QC12 | 5min | 2003-08-03 14:45 | 2003-08-03 14:50 | 231 |  |  |  | 98.99d | 0d |
| 261 | 7.2.10 | AS Observation Data QC13 | 5min | 2003-08-03 17:20 | 2003-08-03 17:25 | 232 |  |  |  | 98.99d | 0d |
| 262 | 7.2.11 | AS Observation Data QC14 | 5min | 2003-08-03 19:55 | 2003-08-03 20:00 | 233 |  |  |  | 98.99d | 0d |
| 263 | 7.2.12 | AS Observation Data QC15 | 5min | 2003-08-03 22:30 | 2003-08-03 22:35 | 234 |  |  |  | 98.99d | 0d |
| 264 | 7.2.13 | AS Observation Data QC16 | 5min | 2003-08-04 01:05 | 2003-08-04 01:10 | 235 |  |  |  | 98.99d | 0d |
| 265 | 7.2.14 | AS Observation Data QC16 | 5min | 2003-08-04 03:40 | 2003-08-04 03:45 | 236 |  |  |  | 98.99d | 0d |
| 266 | 7.2.15 | AS Observation Data QC16 | 5min | 2003-08-04 06:15 | 2003-08-04 06:20 | 237 |  |  |  | 98.99d | 0d |
| 267 | 7.2.16 | AS Observation Data QC16 | 5min | 2003-08-04 08:50 | 2003-08-04 08:55 | 238 |  |  |  | 98.99d | 0d |
| 268 | 7.2.17 | AS Observation Data QC16 | 5min | 2003-08-04 11:25 | 2003-08-04 11:30 | 239 |  |  |  | 98.99d | 0d |
| 269 | 7.2.18 | AS Observation Data QC16 | 5min | 2003-08-04 14:00 | 2003-08-04 14:05 | 240 |  |  |  | 98.99d | 0d |
| 270 | 7.2.19 | AS Observation Data QC16 | 5min | 2003-08-04 16:35 | 2003-08-04 16:40 | 241 |  |  |  | 98.99d | 0d |
| 271 | 7.2.20 | AS Observation Data QC16 | 5min | 2003-08-04 19:10 | 2003-08-04 19:15 | 242 |  |  |  | 98.99d | 0d |
| 272 | 7.2.21 | AS Observation Data QC16 | 5min | 2003-08-04 21:45 | 2003-08-04 21:50 | 243 |  |  |  | 98.99d | 0d |
| 273 | 7.2.22 | AS Observation Data QC16 | 5min | 2003-08-05 00:20 | 2003-08-05 00:25 | 244 |  |  |  | 98.99d | 0d |
| 274 | 7.2.23 | AS Observation Data QC16 | 5min | 2003-08-05 02:55 | 2003-08-05 03:00 | 245 |  |  |  | 98.99d | 0d |
| 275 | 7.2.24 | AS Observation Data QC16 | 5min | 2003-08-05 05:30 | 2003-08-05 05:35 | 246 |  |  |  | 98.99d | 0d |
| 276 | 7.2.25 | AS Observation Data QC16 | 5min | 2003-08-05 08:05 | 2003-08-05 08:10 | 247 |  |  |  | 98.99d | 0d |
| 277 | 7.2.26 | AS Observation Data QC16 | 5min | 2003-08-05 10:40 | 2003-08-05 10:45 | 248 |  |  |  | 98.99d | 0d |
| 278 | 7.2.27 | AS Observation Data QC16 | 5min | 2003-08-05 13:15 | 2003-08-05 13:20 | 249 |  |  |  | 98.99d | 0d |
| 279 | 7.2.28 | AS Observation Data QC16 | 5min | 2003-08-05 15:50 | 2003-08-05 15:55 | 250 |  |  |  | 98.99d | 0d |

| ID | WBS | Task | Duration | Start | Finish | Predecessors | Baseline start | Baseline finish | Baseline duration | Total slack | Free slack |
| --- | --- | --- | --- | --- | --- | --- | --- | --- | --- | --- | --- |
| 280 | 7.3 | **AS Feedback Control** | 8.74d | 2003-08-02 18:10 | 2003-08-05 16:05 |  | 2003-07-14 08:00 | 2003-08-02 21:33 | 58.69d | 98.99d |  |
| 281 | 7.3.1 | AS Feedback Control 2 | 10min | 2003-08-02 18:10 | 2003-08-02 18:20 | 252 |  |  |  | 98.99d | 0d |
| 282 | 7.3.2 | AS Feedback Control 2 | 10min | 2003-08-02 20:45 | 2003-08-02 20:55 | 253 |  |  |  | 98.99d | 0d |
| 283 | 7.3.3 | AS Feedback Control 2 | 10min | 2003-08-02 23:20 | 2003-08-02 23:30 | 254 |  |  |  | 98.99d | 0d |
| 284 | 7.3.4 | AS Feedback Control 2 | 10min | 2003-08-03 01:55 | 2003-08-03 02:05 | 255 |  |  |  | 98.99d | 0d |
| 285 | 7.3.5 | AS Feedback Control 2 | 10min | 2003-08-03 04:30 | 2003-08-03 04:40 | 256 |  |  |  | 98.99d | 0d |
| 286 | 7.3.6 | AS Feedback Control 2 | 10min | 2003-08-03 07:05 | 2003-08-03 07:15 | 257 |  |  |  | 98.99d | 0d |
| 287 | 7.3.7 | AS Feedback Control 2 | 10min | 2003-08-03 09:40 | 2003-08-03 09:50 | 258 |  |  |  | 98.99d | 0d |
| 288 | 7.3.8 | AS Feedback Control 2 | 10min | 2003-08-03 12:15 | 2003-08-03 12:25 | 259 |  |  |  | 98.99d | 0d |
| 289 | 7.3.9 | AS Feedback Control 2 | 10min | 2003-08-03 14:50 | 2003-08-03 15:00 | 260 |  |  |  | 98.99d | 0d |
| 290 | 7.3.10 | AS Feedback Control 2 | 10min | 2003-08-03 17:25 | 2003-08-03 17:35 | 261 |  |  |  | 98.99d | 0d |
| 291 | 7.3.11 | AS Feedback Control 2 | 10min | 2003-08-03 20:00 | 2003-08-03 20:10 | 262 |  |  |  | 98.99d | 0d |
| 292 | 7.3.12 | AS Feedback Control 2 | 10min | 2003-08-03 22:35 | 2003-08-03 22:45 | 263 |  |  |  | 98.99d | 0d |
| 293 | 7.3.13 | AS Feedback Control 2 | 10min | 2003-08-04 01:10 | 2003-08-04 01:20 | 264 |  |  |  | 98.99d | 0d |
| 294 | 7.3.14 | AS Feedback Control 2 | 10min | 2003-08-04 03:45 | 2003-08-04 03:55 | 265 |  |  |  | 98.99d | 0d |
| 295 | 7.3.15 | AS Feedback Control 2 | 10min | 2003-08-04 06:20 | 2003-08-04 06:30 | 266 |  |  |  | 98.99d | 0d |
| 296 | 7.3.16 | AS Feedback Control 2 | 10min | 2003-08-04 08:55 | 2003-08-04 09:05 | 267 |  |  |  | 98.99d | 0d |
| 297 | 7.3.17 | AS Feedback Control 2 | 10min | 2003-08-04 11:30 | 2003-08-04 11:40 | 268 |  |  |  | 98.99d | 0d |
| 298 | 7.3.18 | AS Feedback Control 2 | 10min | 2003-08-04 14:05 | 2003-08-04 14:15 | 269 |  |  |  | 98.99d | 0d |
| 299 | 7.3.19 | AS Feedback Control 2 | 10min | 2003-08-04 16:40 | 2003-08-04 16:50 | 270 |  |  |  | 98.99d | 0d |
| 300 | 7.3.20 | AS Feedback Control 2 | 10min | 2003-08-04 19:15 | 2003-08-04 19:25 | 271 |  |  |  | 98.99d | 0d |
| 301 | 7.3.21 | AS Feedback Control 2 | 10min | 2003-08-04 21:50 | 2003-08-04 22:00 | 272 |  |  |  | 98.99d | 0d |
| 302 | 7.3.22 | AS Feedback Control 2 | 10min | 2003-08-05 00:25 | 2003-08-05 00:35 | 273 |  |  |  | 98.99d | 0d |
| 303 | 7.3.23 | AS Feedback Control 2 | 10min | 2003-08-05 03:00 | 2003-08-05 03:10 | 274 |  |  |  | 98.99d | 0d |
| 304 | 7.3.24 | AS Feedback Control 2 | 10min | 2003-08-05 05:35 | 2003-08-05 05:45 | 275 |  |  |  | 98.99d | 0d |
| 305 | 7.3.25 | AS Feedback Control 2 | 10min | 2003-08-05 08:10 | 2003-08-05 08:20 | 276 |  |  |  | 98.99d | 0d |
| 306 | 7.3.26 | AS Feedback Control 2 | 10min | 2003-08-05 10:45 | 2003-08-05 10:55 | 277 |  |  |  | 98.99d | 0d |
| 307 | 7.3.27 | AS Feedback Control 2 | 10min | 2003-08-05 13:20 | 2003-08-05 13:30 | 278 |  |  |  | 98.99d | 0d |
| 308 | 7.3.28 | AS Feedback Control 2 | 10min | 2003-08-05 15:55 | 2003-08-05 16:05 | 279 |  |  |  | 98.99d | 0d |

| ID | WBS | Task | Type | Duration | Start | Finish | Predecessors | Baseline start | Baseline finish | Baseline duration | Total slack | Free slack |
| --- | --- | --- | --- | --- | --- | --- | --- | --- | --- | --- | --- | --- |
| 309 | 7.4 | **AS Glider Dive** |  | 8.72d | 2003-08-02 18:20 | 2003-08-05 16:05 |  | 2003-07-14 08:10 | 2003-08-02 08:35 | 57.05d | 98.99d |  |
| 310 | 7.4.1 | AS Glider Dive 2 | milestone | 0h | 2003-08-02 18:20 | 2003-08-02 18:20 | 281 |  |  |  | 98.99d | 0d |
| 311 | 7.4.2 | AS Glider Dive 2 | milestone | 0h | 2003-08-02 20:55 | 2003-08-02 20:55 | 282 |  |  |  | 98.99d | 0d |
| 312 | 7.4.3 | AS Glider Dive 2 | milestone | 0h | 2003-08-02 23:30 | 2003-08-02 23:30 | 283 |  |  |  | 98.99d | 0d |
| 313 | 7.4.4 | AS Glider Dive 2 | milestone | 0h | 2003-08-03 02:05 | 2003-08-03 02:05 | 284 |  |  |  | 98.99d | 0d |
| 314 | 7.4.5 | AS Glider Dive 2 | milestone | 0h | 2003-08-03 04:40 | 2003-08-03 04:40 | 285 |  |  |  | 98.99d | 0d |
| 315 | 7.4.6 | AS Glider Dive 2 | milestone | 0h | 2003-08-03 07:15 | 2003-08-03 07:15 | 286 |  |  |  | 98.99d | 0d |
| 316 | 7.4.7 | AS Glider Dive 2 | milestone | 0h | 2003-08-03 09:50 | 2003-08-03 09:50 | 287 |  |  |  | 98.99d | 0d |
| 317 | 7.4.8 | AS Glider Dive 2 | milestone | 0h | 2003-08-03 12:25 | 2003-08-03 12:25 | 288 |  |  |  | 98.99d | 0d |
| 318 | 7.4.9 | AS Glider Dive 2 | milestone | 0h | 2003-08-03 15:00 | 2003-08-03 15:00 | 289 |  |  |  | 98.99d | 0d |
| 319 | 7.4.10 | AS Glider Dive 2 | milestone | 0h | 2003-08-03 17:35 | 2003-08-03 17:35 | 290 |  |  |  | 98.99d | 0d |
| 320 | 7.4.11 | AS Glider Dive 2 | milestone | 0h | 2003-08-03 20:10 | 2003-08-03 20:10 | 291 |  |  |  | 98.99d | 0d |
| 321 | 7.4.12 | AS Glider Dive 2 | milestone | 0h | 2003-08-03 22:45 | 2003-08-03 22:45 | 292 |  |  |  | 98.99d | 0d |
| 322 | 7.4.13 | AS Glider Dive 2 | milestone | 0h | 2003-08-04 01:20 | 2003-08-04 01:20 | 293 |  |  |  | 98.99d | 0d |
| 323 | 7.4.14 | AS Glider Dive 2 | milestone | 0h | 2003-08-04 03:55 | 2003-08-04 03:55 | 294 |  |  |  | 98.99d | 0d |
| 324 | 7.4.15 | AS Glider Dive 2 | milestone | 0h | 2003-08-04 06:30 | 2003-08-04 06:30 | 295 |  |  |  | 98.99d | 0d |
| 325 | 7.4.16 | AS Glider Dive 2 | milestone | 0h | 2003-08-04 09:05 | 2003-08-04 09:05 | 296 |  |  |  | 98.99d | 0d |
| 326 | 7.4.17 | AS Glider Dive 2 | milestone | 0h | 2003-08-04 11:40 | 2003-08-04 11:40 | 297 |  |  |  | 98.99d | 0d |
| 327 | 7.4.18 | AS Glider Dive 2 | milestone | 0h | 2003-08-04 14:15 | 2003-08-04 14:15 | 298 |  |  |  | 98.99d | 0d |
| 328 | 7.4.19 | AS Glider Dive 2 | milestone | 0h | 2003-08-04 16:50 | 2003-08-04 16:50 | 299 |  |  |  | 98.99d | 0d |
| 329 | 7.4.20 | AS Glider Dive 2 | milestone | 0h | 2003-08-04 19:25 | 2003-08-04 19:25 | 300 |  |  |  | 98.99d | 0d |
| 330 | 7.4.21 | AS Glider Dive 2 | milestone | 0h | 2003-08-04 22:00 | 2003-08-04 22:00 | 301 |  |  |  | 98.99d | 0d |
| 331 | 7.4.22 | AS Glider Dive 2 | milestone | 0h | 2003-08-05 00:35 | 2003-08-05 00:35 | 302 |  |  |  | 98.99d | 0d |
| 332 | 7.4.23 | AS Glider Dive 2 | milestone | 0h | 2003-08-05 03:10 | 2003-08-05 03:10 | 303 |  |  |  | 98.99d | 0d |
| 333 | 7.4.24 | AS Glider Dive 2 | milestone | 0h | 2003-08-05 05:45 | 2003-08-05 05:45 | 304 |  |  |  | 98.99d | 0d |
| 334 | 7.4.25 | AS Glider Dive 2 | milestone | 0h | 2003-08-05 08:20 | 2003-08-05 08:20 | 305 |  |  |  | 98.99d | 0d |
| 335 | 7.4.26 | AS Glider Dive 2 | milestone | 0h | 2003-08-05 10:55 | 2003-08-05 10:55 | 306 |  |  |  | 98.99d | 0d |
| 336 | 7.4.27 | AS Glider Dive 2 | milestone | 0h | 2003-08-05 13:30 | 2003-08-05 13:30 | 307 |  |  |  | 98.99d | 0d |
| 337 | 7.4.28 | AS Glider Dive 2 | milestone | 0h | 2003-08-05 16:05 | 2003-08-05 16:05 | 308 |  |  |  | 98.99d |  |

| ID | WBS | Task | Duration | Start | Finish | Predecessors | Total slack | Free slack | Constraint |
| --- | --- | --- | --- | --- | --- | --- | --- | --- | --- |
| 338 | 8 | **Slocum Pattern Glider Ops** | 9.5d | 2003-08-02 10:00 | 2003-08-05 14:00 |  | 99.25d |  |  |
| 339 | 8.1 | Glider Surface 1 | 10min | 2003-08-02 10:00 | 2003-08-02 10:10 |  | 99.25d | 0d | start no earlier than 2003-08-02 10:00 |
| 340 | 8.2 | Glider Surface 1 | 10min | 2003-08-02 12:10 | 2003-08-02 12:20 | 339FS+2h | 99.25d | 0d |  |
| 341 | 8.3 | Glider Surface 1 | 10min | 2003-08-02 14:20 | 2003-08-02 14:30 | 340FS+2h | 99.25d | 0d |  |
| 342 | 8.4 | Glider Surface 1 | 10min | 2003-08-02 16:30 | 2003-08-02 16:40 | 341FS+2h | 99.25d | 0d |  |
| 343 | 8.5 | Glider Surface 1 | 10min | 2003-08-02 18:40 | 2003-08-02 18:50 | 342FS+2h | 99.25d | 0d |  |
| 344 | 8.6 | Glider Surface 1 | 10min | 2003-08-02 20:50 | 2003-08-02 21:00 | 343FS+2h | 99.25d | 0d |  |
| 345 | 8.7 | Glider Surface 1 | 10min | 2003-08-02 23:00 | 2003-08-02 23:10 | 344FS+2h | 99.25d | 0d |  |
| 346 | 8.8 | Glider Surface 1 | 10min | 2003-08-03 01:10 | 2003-08-03 01:20 | 345FS+2h | 99.25d | 0d |  |
| 347 | 8.9 | Glider Surface 1 | 10min | 2003-08-03 03:20 | 2003-08-03 03:30 | 346FS+2h | 99.25d | 0d |  |
| 348 | 8.10 | Glider Surface 1 | 10min | 2003-08-03 05:30 | 2003-08-03 05:40 | 347FS+2h | 99.25d | 0d |  |
| 349 | 8.11 | Glider Surface 1 | 10min | 2003-08-03 07:40 | 2003-08-03 07:50 | 348FS+2h | 99.25d | 0d |  |
| 350 | 8.12 | Glider Surface 1 | 10min | 2003-08-03 09:50 | 2003-08-03 10:00 | 349FS+2h | 99.25d | 0d |  |
| 351 | 8.13 | Glider Surface 1 | 10min | 2003-08-03 12:00 | 2003-08-03 12:10 | 350FS+2h | 99.25d | 0d |  |
| 352 | 8.14 | Glider Surface 1 | 10min | 2003-08-03 14:10 | 2003-08-03 14:20 | 351FS+2h | 99.25d | 0d |  |
| 353 | 8.15 | Glider Surface 1 | 10min | 2003-08-03 16:20 | 2003-08-03 16:30 | 352FS+2h | 99.25d | 0d |  |
| 354 | 8.16 | Glider Surface 1 | 10min | 2003-08-03 18:30 | 2003-08-03 18:40 | 353FS+2h | 99.25d | 0d |  |
| 355 | 8.17 | Glider Surface 1 | 10min | 2003-08-03 20:40 | 2003-08-03 20:50 | 354FS+2h | 99.25d | 0d |  |
| 356 | 8.18 | Glider Surface 1 | 10min | 2003-08-03 22:50 | 2003-08-03 23:00 | 355FS+2h | 99.25d | 0d |  |
| 357 | 8.19 | Glider Surface 1 | 10min | 2003-08-04 01:00 | 2003-08-04 01:10 | 356FS+2h | 99.25d | 0d |  |
| 358 | 8.20 | Glider Surface 1 | 10min | 2003-08-04 03:10 | 2003-08-04 03:20 | 357FS+2h | 99.25d | 0d |  |
| 359 | 8.21 | Glider Surface 1 | 10min | 2003-08-04 05:20 | 2003-08-04 05:30 | 358FS+2h | 99.25d | 0d |  |
| 360 | 8.22 | Glider Surface 1 | 10min | 2003-08-04 07:30 | 2003-08-04 07:40 | 359FS+2h | 99.25d | 0d |  |
| 361 | 8.23 | Glider Surface 1 | 10min | 2003-08-04 09:40 | 2003-08-04 09:50 | 360FS+2h | 99.25d | 0d |  |
| 362 | 8.24 | Glider Surface 1 | 10min | 2003-08-04 11:50 | 2003-08-04 12:00 | 361FS+2h | 99.25d | 0d |  |
| 363 | 8.25 | Glider Surface 1 | 10min | 2003-08-04 14:00 | 2003-08-04 14:10 | 362FS+2h | 99.25d | 0d |  |
| 364 | 8.26 | Glider Surface 1 | 10min | 2003-08-04 16:10 | 2003-08-04 16:20 | 363FS+2h | 99.25d | 0d |  |
| 365 | 8.27 | Glider Surface 1 | 10min | 2003-08-04 18:20 | 2003-08-04 18:30 | 364FS+2h | 99.25d | 0d |  |
| 366 | 8.28 | Glider Surface 1 | 10min | 2003-08-04 20:30 | 2003-08-04 20:40 | 365FS+2h | 99.25d | 0d |  |
| 367 | 8.29 | Glider Surface 1 | 10min | 2003-08-04 22:40 | 2003-08-04 22:50 | 366FS+2h | 99.25d | 0d |  |
| 368 | 8.30 | Glider Surface 1 | 10min | 2003-08-05 00:50 | 2003-08-05 01:00 | 367FS+2h | 99.25d | 0d |  |
| 369 | 8.31 | Glider Surface 1 | 10min | 2003-08-05 03:00 | 2003-08-05 03:10 | 368FS+2h | 99.25d | 0d |  |
| 370 | 8.32 | Glider Surface 1 | 10min | 2003-08-05 05:10 | 2003-08-05 05:20 | 369FS+2h | 99.25d | 0d |  |
| 371 | 8.33 | Glider Surface 1 | 10min | 2003-08-05 07:20 | 2003-08-05 07:30 | 370FS+2h | 99.25d | 0d |  |
| 372 | 8.34 | Glider Surface 1 | 10min | 2003-08-05 09:30 | 2003-08-05 09:40 | 371FS+2h | 99.25d | 0d |  |
| 373 | 8.35 | Glider Surface 1 | 10min | 2003-08-05 11:40 | 2003-08-05 11:50 | 372FS+2h | 99.25d | 0d |  |
| 374 | 8.36 | Glider Surface 1 | 10min | 2003-08-05 13:50 | 2003-08-05 14:00 | 373FS+2h | 99.25d |  |  |

| ID | WBS | Task | Type | Duration | Start | Finish | Baseline start | Baseline finish | Baseline duration | Total slack | Constraint |
| --- | --- | --- | --- | --- | --- | --- | --- | --- | --- | --- | --- |
| 375 | 9 | **Spray Glider Data Avail** |  | 108d | 2003-08-02 16:00 | 2003-09-07 16:00 | 2003-08-02 10:00 | 2003-09-07 10:00 | 108d | 0d |  |
| 376 | 9.1 | Slocum Glider Data Avail 1 | milestone | 0h | 2003-08-02 16:00 | 2003-08-02 16:00 | 2003-08-02 10:00 | 2003-08-02 10:00 | 0h | 108d | start no earlier than 2003-08-02 16:00 |
| 377 | 9.2 | Slocum Glider Data Avail 2 | milestone | 0h | 2003-08-03 16:00 | 2003-08-03 16:00 | 2003-08-03 10:00 | 2003-08-03 10:00 | 0h | 105d | start no earlier than 2003-08-03 16:00 |
| 378 | 9.3 | Slocum Glider Data Avail 3 | milestone | 0h | 2003-08-04 16:00 | 2003-08-04 16:00 | 2003-08-04 10:00 | 2003-08-04 10:00 | 0h | 102d | start no earlier than 2003-08-04 16:00 |
| 379 | 9.4 | Slocum Glider Data Avail 4 | milestone | 0h | 2003-08-05 16:00 | 2003-08-05 16:00 | 2003-08-05 10:00 | 2003-08-05 10:00 | 0h | 99d | start no earlier than 2003-08-05 16:00 |
| 380 | 9.5 | Slocum Glider Data Avail 5 | milestone | 0h | 2003-08-06 16:00 | 2003-08-06 16:00 | 2003-08-06 10:00 | 2003-08-06 10:00 | 0h | 96d | start no earlier than 2003-08-06 16:00 |
| 381 | 9.6 | Slocum Glider Data Avail 6 | milestone | 0h | 2003-08-07 16:00 | 2003-08-07 16:00 | 2003-08-07 10:00 | 2003-08-07 10:00 | 0h | 93d | start no earlier than 2003-08-07 16:00 |
| 382 | 9.7 | Slocum Glider Data Avail 7 | milestone | 0h | 2003-08-08 16:00 | 2003-08-08 16:00 | 2003-08-08 10:00 | 2003-08-08 10:00 | 0h | 90d | start no earlier than 2003-08-08 16:00 |
| 383 | 9.8 | Slocum Glider Data Avail 8 | milestone | 0h | 2003-08-09 16:00 | 2003-08-09 16:00 | 2003-08-09 10:00 | 2003-08-09 10:00 | 0h | 87d | start no earlier than 2003-08-09 16:00 |
| 384 | 9.9 | Slocum Glider Data Avail 9 | milestone | 0h | 2003-08-10 16:00 | 2003-08-10 16:00 | 2003-08-10 10:00 | 2003-08-10 10:00 | 0h | 84d | start no earlier than 2003-08-10 16:00 |
| 385 | 9.10 | Slocum Glider Data Avail 10 | milestone | 0h | 2003-08-11 16:00 | 2003-08-11 16:00 | 2003-08-11 10:00 | 2003-08-11 10:00 | 0h | 81d | start no earlier than 2003-08-11 16:00 |
| 386 | 9.11 | Slocum Glider Data Avail 11 | milestone | 0h | 2003-08-12 16:00 | 2003-08-12 16:00 | 2003-08-12 10:00 | 2003-08-12 10:00 | 0h | 78d | start no earlier than 2003-08-12 16:00 |
| 387 | 9.12 | Slocum Glider Data Avail 12 | milestone | 0h | 2003-08-13 16:00 | 2003-08-13 16:00 | 2003-08-13 10:00 | 2003-08-13 10:00 | 0h | 75d | start no earlier than 2003-08-13 16:00 |
| 388 | 9.13 | Slocum Glider Data Avail 13 | milestone | 0h | 2003-08-14 16:00 | 2003-08-14 16:00 | 2003-08-14 10:00 | 2003-08-14 10:00 | 0h | 72d | start no earlier than 2003-08-14 16:00 |
| 389 | 9.14 | Slocum Glider Data Avail 14 | milestone | 0h | 2003-08-15 16:00 | 2003-08-15 16:00 | 2003-08-15 10:00 | 2003-08-15 10:00 | 0h | 69d | start no earlier than 2003-08-15 16:00 |
| 390 | 9.15 | Slocum Glider Data Avail 15 | milestone | 0h | 2003-08-16 16:00 | 2003-08-16 16:00 | 2003-08-16 10:00 | 2003-08-16 10:00 | 0h | 66d | start no earlier than 2003-08-16 16:00 |
| 391 | 9.16 | Slocum Glider Data Avail 16 | milestone | 0h | 2003-08-17 16:00 | 2003-08-17 16:00 | 2003-08-17 10:00 | 2003-08-17 10:00 | 0h | 63d | start no earlier than 2003-08-17 16:00 |
| 392 | 9.17 | Slocum Glider Data Avail 17 | milestone | 0h | 2003-08-18 16:00 | 2003-08-18 16:00 | 2003-08-18 10:00 | 2003-08-18 10:00 | 0h | 60d | start no earlier than 2003-08-18 16:00 |
| 393 | 9.18 | Slocum Glider Data Avail 18 | milestone | 0h | 2003-08-19 16:00 | 2003-08-19 16:00 | 2003-08-19 10:00 | 2003-08-19 10:00 | 0h | 57d | start no earlier than 2003-08-19 16:00 |
| 394 | 9.19 | Slocum Glider Data Avail 19 | milestone | 0h | 2003-08-20 16:00 | 2003-08-20 16:00 | 2003-08-20 10:00 | 2003-08-20 10:00 | 0h | 54d | start no earlier than 2003-08-20 16:00 |
| 395 | 9.20 | Slocum Glider Data Avail 20 | milestone | 0h | 2003-08-21 16:00 | 2003-08-21 16:00 | 2003-08-21 10:00 | 2003-08-21 10:00 | 0h | 51d | start no earlier than 2003-08-21 16:00 |
| 396 | 9.21 | Slocum Glider Data Avail 21 | milestone | 0h | 2003-08-22 16:00 | 2003-08-22 16:00 | 2003-08-22 10:00 | 2003-08-22 10:00 | 0h | 48d | start no earlier than 2003-08-22 16:00 |
| 397 | 9.22 | Slocum Glider Data Avail 22 | milestone | 0h | 2003-08-23 16:00 | 2003-08-23 16:00 | 2003-08-23 10:00 | 2003-08-23 10:00 | 0h | 45d | start no earlier than 2003-08-23 16:00 |
| 398 | 9.23 | Slocum Glider Data Avail 23 | milestone | 0h | 2003-08-24 16:00 | 2003-08-24 16:00 | 2003-08-24 10:00 | 2003-08-24 10:00 | 0h | 42d | start no earlier than 2003-08-24 16:00 |
| 399 | 9.24 | Slocum Glider Data Avail 24 | milestone | 0h | 2003-08-25 16:00 | 2003-08-25 16:00 | 2003-08-25 10:00 | 2003-08-25 10:00 | 0h | 39d | start no earlier than 2003-08-25 16:00 |
| 400 | 9.25 | Slocum Glider Data Avail 25 | milestone | 0h | 2003-08-26 16:00 | 2003-08-26 16:00 | 2003-08-26 10:00 | 2003-08-26 10:00 | 0h | 36d | start no earlier than 2003-08-26 16:00 |
| 401 | 9.26 | Slocum Glider Data Avail 26 | milestone | 0h | 2003-08-27 16:00 | 2003-08-27 16:00 | 2003-08-27 10:00 | 2003-08-27 10:00 | 0h | 33d | start no earlier than 2003-08-27 16:00 |
| 402 | 9.27 | Slocum Glider Data Avail 27 | milestone | 0h | 2003-08-28 16:00 | 2003-08-28 16:00 | 2003-08-28 10:00 | 2003-08-28 10:00 | 0h | 30d | start no earlier than 2003-08-28 16:00 |
| 403 | 9.28 | Slocum Glider Data Avail 28 | milestone | 0h | 2003-08-29 16:00 | 2003-08-29 16:00 | 2003-08-29 10:00 | 2003-08-29 10:00 | 0h | 27d | start no earlier than 2003-08-29 16:00 |
| 404 | 9.29 | Slocum Glider Data Avail 29 | milestone | 0h | 2003-08-30 16:00 | 2003-08-30 16:00 | 2003-08-30 10:00 | 2003-08-30 10:00 | 0h | 24d | start no earlier than 2003-08-30 16:00 |
| 405 | 9.30 | Slocum Glider Data Avail 30 | milestone | 0h | 2003-08-31 16:00 | 2003-08-31 16:00 | 2003-08-31 10:00 | 2003-08-31 10:00 | 0h | 21d | start no earlier than 2003-08-31 16:00 |
| 406 | 9.31 | Slocum Glider Data Avail 31 | milestone | 0h | 2003-09-01 16:00 | 2003-09-01 16:00 | 2003-09-01 10:00 | 2003-09-01 10:00 | 0h | 18d | start no earlier than 2003-09-01 16:00 |
| 407 | 9.32 | Slocum Glider Data Avail 32 | milestone | 0h | 2003-09-02 16:00 | 2003-09-02 16:00 | 2003-09-02 10:00 | 2003-09-02 10:00 | 0h | 15d | start no earlier than 2003-09-02 16:00 |
| 408 | 9.33 | Slocum Glider Data Avail 33 | milestone | 0h | 2003-09-03 16:00 | 2003-09-03 16:00 | 2003-09-03 10:00 | 2003-09-03 10:00 | 0h | 12d | start no earlier than 2003-09-03 16:00 |
| 409 | 9.34 | Slocum Glider Data Avail 34 | milestone | 0h | 2003-09-04 16:00 | 2003-09-04 16:00 | 2003-09-04 10:00 | 2003-09-04 10:00 | 0h | 9d | start no earlier than 2003-09-04 16:00 |
| 410 | 9.35 | Slocum Glider Data Avail 35 | milestone | 0h | 2003-09-05 16:00 | 2003-09-05 16:00 | 2003-09-05 10:00 | 2003-09-05 10:00 | 0h | 6d | start no earlier than 2003-09-05 16:00 |
| 411 | 9.36 | Slocum Glider Data Avail 36 | milestone | 0h | 2003-09-06 16:00 | 2003-09-06 16:00 | 2003-09-06 10:00 | 2003-09-06 10:00 | 0h | 3d | start no earlier than 2003-09-06 16:00 |
| 412 | 9.37 | Slocum Glider Data Avail 37 | milestone | 0h | 2003-09-07 16:00 | 2003-09-07 16:00 | 2003-09-07 10:00 | 2003-09-07 10:00 | 0h | 0d | start no earlier than 2003-09-07 16:00 |

| ID | WBS | Task | Type | Duration | Start | Finish | Predecessors | Total slack | Free slack | Constraint |
| --- | --- | --- | --- | --- | --- | --- | --- | --- | --- | --- |
| 413 | 10 | **Twin Otter Flight Ops** |  | 13d | 2003-08-02 12:00 | 2003-08-06 20:00 |  | 95.5d |  |  |
| 414 | 10.1 | **Twin Otter Flights** |  | 13d | 2003-08-02 12:00 | 2003-08-06 20:00 |  | 95.5d |  |  |
| 415 | 10.1.1 | Twin Otter Flight 1 |  | 4h | 2003-08-02 12:00 | 2003-08-02 16:00 |  | 107.5d | 0d | start no earlier than 2003-08-02 12:00 |
| 416 | 10.1.2 | Twin Otter Flight 2 |  | 4h | 2003-08-04 08:00 | 2003-08-04 12:00 |  | 102d | 0d | start no earlier than 2003-08-04 08:00 |
| 417 | 10.1.3 | Twin Oter Flight 3 |  | 4h | 2003-08-06 12:00 | 2003-08-06 16:00 |  | 95.5d | 0d | start no earlier than 2003-08-06 12:00 |
| 418 | 10.1.4 | **Twin Otter Data Reduction** |  | 12.5d | 2003-08-02 16:00 | 2003-08-06 20:00 |  | 95.5d |  |  |
| 419 | 10.1.4.1 | Twin otter DR 1 |  | 4h | 2003-08-02 16:00 | 2003-08-02 20:00 | 415 | 107.5d | 0d |  |
| 420 | 10.1.4.2 | Twin Otter DR 2 |  | 4h | 2003-08-04 12:00 | 2003-08-04 16:00 | 416 | 102d | 0d |  |
| 421 | 10.1.4.3 | Twin Otter DR 3 |  | 4h | 2003-08-06 16:00 | 2003-08-06 20:00 | 417 | 95.5d | 0d |  |
| 422 | 10.1.5 | **Twin Otter Data to RTOC** |  | 12d | 2003-08-02 20:00 | 2003-08-06 20:00 |  | 95.5d |  |  |
| 423 | 10.1.5.1 | Day 1 | milestone | 0h | 2003-08-02 20:00 | 2003-08-02 20:00 | 419 | 107.5d |  |  |
| 424 | 10.1.5.2 | Day 2 | milestone | 0h | 2003-08-04 16:00 | 2003-08-04 16:00 | 420 | 102d |  |  |
| 425 | 10.1.5.3 | Day 3 | milestone | 0h | 2003-08-06 20:00 | 2003-08-06 20:00 | 421 | 95.5d |  |  |
| 426 | 11 | CODAR Data |  | 135.98h | 2003-08-02 08:00 | 2003-08-07 23:59 |  | 92d |  | start no earlier than 2003-08-02 08:00 |
| 427 | 12 | Surface Met Data |  | 135.98h | 2003-08-02 08:00 | 2003-08-07 23:59 |  | 92d |  | start no earlier than 2003-08-02 08:00 |
| 428 | 13 | **ADCP Data** |  | 11d | 2003-08-02 16:00 | 2003-08-06 08:00 |  | 97d |  |  |
| 429 | 13.1 | ADCP Data 1 | milestone | 0h | 2003-08-02 16:00 | 2003-08-02 16:00 |  | 108d |  | start no earlier than 2003-08-02 16:00 |
| 430 | 13.2 | ADCP Data 2 | milestone | 0h | 2003-08-04 08:00 | 2003-08-04 08:00 |  | 103d |  | start no earlier than 2003-08-04 08:00 |
| 431 | 13.3 | ADCP Data 3 | milestone | 0h | 2003-08-06 08:00 | 2003-08-06 08:00 |  | 97d |  | start no earlier than 2003-08-06 08:00 |
| 432 | 14 | **Mooring Data** |  | 6d | 2003-08-02 16:00 | 2003-08-04 16:00 |  | 102d |  |  |
| 433 | 14.1 | **M1 Data Fields** |  | 6d | 2003-08-02 16:00 | 2003-08-04 16:00 |  | 102d |  |  |
| 434 | 14.1.1 | M1 Day 1 | milestone | 0h | 2003-08-02 16:00 | 2003-08-02 16:00 |  | 108d |  | start no earlier than 2003-08-02 16:00 |
| 435 | 14.1.2 | M1 Day 2 | milestone | 0h | 2003-08-03 16:00 | 2003-08-03 16:00 |  | 105d |  | start no earlier than 2003-08-03 16:00 |
| 436 | 14.1.3 | M1 Day 3 | milestone | 0h | 2003-08-04 16:00 | 2003-08-04 16:00 |  | 102d |  | start no earlier than 2003-08-04 16:00 |

| ID | WBS | Task | Type | Duration | Start | Finish | Total slack | Constraint |
| --- | --- | --- | --- | --- | --- | --- | --- | --- |
| 437 | 14.2 | **M2 Data Fields** |  | 6d | 2003-08-02 16:00 | 2003-08-04 16:00 | 102d |  |
| 438 | 14.2.1 | M2 Day 1 | milestone | 0h | 2003-08-02 16:00 | 2003-08-02 16:00 | 108d | start no earlier than 2003-08-02 16:00 |
| 439 | 14.2.2 | M2 Day 2 | milestone | 0h | 2003-08-03 16:00 | 2003-08-03 16:00 | 105d | start no earlier than 2003-08-03 16:00 |
| 440 | 14.2.3 | M2 Day 3 | milestone | 0h | 2003-08-04 16:00 | 2003-08-04 16:00 | 102d | start no earlier than 2003-08-04 16:00 |
| 441 | 15 | **COAMPS Data** |  | 15d | 2003-08-02 15:00 | 2003-08-07 15:00 | 93.12d |  |
| 442 | 15.1 | COAMPS Data 1 | milestone | 0h | 2003-08-02 15:00 | 2003-08-02 15:00 | 108.12d | start no earlier than 2003-08-02 15:00 |
| 443 | 15.2 | COAMPS Data 2 | milestone | 0h | 2003-08-03 15:00 | 2003-08-03 15:00 | 105.12d | start no earlier than 2003-08-03 15:00 |
| 444 | 15.3 | COAMPS Data 3 | milestone | 0h | 2003-08-04 15:00 | 2003-08-04 15:00 | 102.12d | start no earlier than 2003-08-04 15:00 |
| 445 | 15.4 | COAMPS Data 4 | milestone | 0h | 2003-08-05 15:00 | 2003-08-05 15:00 | 99.12d | start no earlier than 2003-08-05 15:00 |
| 446 | 15.5 | COAMPS Data 5 | milestone | 0h | 2003-08-06 15:00 | 2003-08-06 15:00 | 96.12d | start no earlier than 2003-08-06 15:00 |
| 447 | 15.6 | COAMPS Data 6 | milestone | 0h | 2003-08-07 15:00 | 2003-08-07 15:00 | 93.12d | start no earlier than 2003-08-07 15:00 |
| 448 | 16 | **hydrography reporting** |  | 108d | 2003-08-02 16:00 | 2003-09-07 16:00 | 0d |  |
| 449 | 16.1 | hydrography reporting 1 | milestone | 0h | 2003-08-02 16:00 | 2003-08-02 16:00 | 108d | start no earlier than 2003-08-02 16:00 |
| 450 | 16.2 | hydrography reporting 2 | milestone | 0h | 2003-08-03 16:00 | 2003-08-03 16:00 | 105d | start no earlier than 2003-08-03 16:00 |
| 451 | 16.3 | hydrography reporting 3 | milestone | 0h | 2003-08-04 16:00 | 2003-08-04 16:00 | 102d | start no earlier than 2003-08-04 16:00 |
| 452 | 16.4 | hydrography reporting 4 | milestone | 0h | 2003-08-05 16:00 | 2003-08-05 16:00 | 99d | start no earlier than 2003-08-05 16:00 |
| 453 | 16.5 | hydrography reporting 5 | milestone | 0h | 2003-08-06 16:00 | 2003-08-06 16:00 | 96d | start no earlier than 2003-08-06 16:00 |
| 454 | 16.6 | hydrography reporting 6 | milestone | 0h | 2003-08-07 16:00 | 2003-08-07 16:00 | 93d | start no earlier than 2003-08-07 16:00 |
| 455 | 16.7 | hydrography reporting 7 | milestone | 0h | 2003-08-08 16:00 | 2003-08-08 16:00 | 90d | start no earlier than 2003-08-08 16:00 |
| 456 | 16.8 | hydrography reporting 8 | milestone | 0h | 2003-08-09 16:00 | 2003-08-09 16:00 | 87d | start no earlier than 2003-08-09 16:00 |
| 457 | 16.9 | hydrography reporting 9 | milestone | 0h | 2003-08-10 16:00 | 2003-08-10 16:00 | 84d | start no earlier than 2003-08-10 16:00 |
| 458 | 16.10 | hydrography reporting 10 | milestone | 0h | 2003-08-11 16:00 | 2003-08-11 16:00 | 81d | start no earlier than 2003-08-11 16:00 |
| 459 | 16.11 | hydrography reporting 11 | milestone | 0h | 2003-08-12 16:00 | 2003-08-12 16:00 | 78d | start no earlier than 2003-08-12 16:00 |
| 460 | 16.12 | hydrography reporting 12 | milestone | 0h | 2003-08-13 16:00 | 2003-08-13 16:00 | 75d | start no earlier than 2003-08-13 16:00 |
| 461 | 16.13 | hydrography reporting 13 | milestone | 0h | 2003-08-14 16:00 | 2003-08-14 16:00 | 72d | start no earlier than 2003-08-14 16:00 |
| 462 | 16.14 | hydrography reporting 14 | milestone | 0h | 2003-08-15 16:00 | 2003-08-15 16:00 | 69d | start no earlier than 2003-08-15 16:00 |
| 463 | 16.15 | hydrography reporting 15 | milestone | 0h | 2003-08-16 16:00 | 2003-08-16 16:00 | 66d | start no earlier than 2003-08-16 16:00 |
| 464 | 16.16 | hydrography reporting 16 | milestone | 0h | 2003-08-17 16:00 | 2003-08-17 16:00 | 63d | start no earlier than 2003-08-17 16:00 |
| 465 | 16.17 | hydrography reporting 17 | milestone | 0h | 2003-08-18 16:00 | 2003-08-18 16:00 | 60d | start no earlier than 2003-08-18 16:00 |
| 466 | 16.18 | hydrography reporting 18 | milestone | 0h | 2003-08-19 16:00 | 2003-08-19 16:00 | 57d | start no earlier than 2003-08-19 16:00 |
| 467 | 16.19 | hydrography reporting 19 | milestone | 0h | 2003-08-20 16:00 | 2003-08-20 16:00 | 54d | start no earlier than 2003-08-20 16:00 |
| 468 | 16.20 | hydrography reporting 20 | milestone | 0h | 2003-08-21 16:00 | 2003-08-21 16:00 | 51d | start no earlier than 2003-08-21 16:00 |
| 469 | 16.21 | hydrography reporting 21 | milestone | 0h | 2003-08-22 16:00 | 2003-08-22 16:00 | 48d | start no earlier than 2003-08-22 16:00 |
| 470 | 16.22 | hydrography reporting 22 | milestone | 0h | 2003-08-23 16:00 | 2003-08-23 16:00 | 45d | start no earlier than 2003-08-23 16:00 |
| 471 | 16.23 | hydrography reporting 23 | milestone | 0h | 2003-08-24 16:00 | 2003-08-24 16:00 | 42d | start no earlier than 2003-08-24 16:00 |
| 472 | 16.24 | hydrography reporting 24 | milestone | 0h | 2003-08-25 16:00 | 2003-08-25 16:00 | 39d | start no earlier than 2003-08-25 16:00 |
| 473 | 16.25 | hydrography reporting 25 | milestone | 0h | 2003-08-26 16:00 | 2003-08-26 16:00 | 36d | start no earlier than 2003-08-26 16:00 |
| 474 | 16.26 | hydrography reporting 26 | milestone | 0h | 2003-08-27 16:00 | 2003-08-27 16:00 | 33d | start no earlier than 2003-08-27 16:00 |
| 475 | 16.27 | hydrography reporting 27 | milestone | 0h | 2003-08-28 16:00 | 2003-08-28 16:00 | 30d | start no earlier than 2003-08-28 16:00 |
| 476 | 16.28 | hydrography reporting 28 | milestone | 0h | 2003-08-29 16:00 | 2003-08-29 16:00 | 27d | start no earlier than 2003-08-29 16:00 |
| 477 | 16.29 | hydrography reporting 29 | milestone | 0h | 2003-08-30 16:00 | 2003-08-30 16:00 | 24d | start no earlier than 2003-08-30 16:00 |
| 478 | 16.30 | hydrography reporting 30 | milestone | 0h | 2003-08-31 16:00 | 2003-08-31 16:00 | 21d | start no earlier than 2003-08-31 16:00 |
| 479 | 16.31 | hydrography reporting 31 | milestone | 0h | 2003-09-01 16:00 | 2003-09-01 16:00 | 18d | start no earlier than 2003-09-01 16:00 |
| 480 | 16.32 | hydrography reporting 32 | milestone | 0h | 2003-09-02 16:00 | 2003-09-02 16:00 | 15d | start no earlier than 2003-09-02 16:00 |
| 481 | 16.33 | hydrography reporting 33 | milestone | 0h | 2003-09-03 16:00 | 2003-09-03 16:00 | 12d | start no earlier than 2003-09-03 16:00 |
| 482 | 16.34 | hydrography reporting 34 | milestone | 0h | 2003-09-04 16:00 | 2003-09-04 16:00 | 9d | start no earlier than 2003-09-04 16:00 |
| 483 | 16.35 | hydrography reporting 35 | milestone | 0h | 2003-09-05 16:00 | 2003-09-05 16:00 | 6d | start no earlier than 2003-09-05 16:00 |
| 484 | 16.36 | hydrography reporting 36 | milestone | 0h | 2003-09-06 16:00 | 2003-09-06 16:00 | 3d | start no earlier than 2003-09-06 16:00 |
| 485 | 16.37 | hydrography reporting 37 | milestone | 0h | 2003-09-07 16:00 | 2003-09-07 16:00 | 0d | start no earlier than 2003-09-07 16:00 |
